# YMorinSem3

Schedule from MS Project, 2002-01-21 to 2002-05-02, status date 2002-02-09, 7 hours a day, costs in $, A marks actual dates.
Cégep de St-Jérôme

## Calendars

- Yan Morin: Mon-Thu 09:00-12:00, 13:00-17:00; Fri-Sun off.

## Resources

| Resource | Rate |
| --- | --- |
| Yan Morin |  |
| Boris Nacinovic | 10 |
| Emmanuelle Forger - Comptable |  |
| Gilles Juteau - Vice-président, directeur marketing |  |

## Schedule

| ID | WBS | Task | Duration | Start | Finish | Predecessors | Complete | Constraint | Resources | Work | Actual work | Cost | Actual cost |
| --- | --- | --- | --- | --- | --- | --- | --- | --- | --- | --- | --- | --- | --- |
| 1 | 1 | **Introduction en entreprise** | 1d | 2002-01-21 09:00 A | 2002-01-21 17:00 A |  | 100% |  |  | 10.5h | 10.5h | 35 | 35 |
| 2 | 1.1 | Apprentissage de l'environnement Visual Basic | 3.5h | 2002-01-21 09:00 A | 2002-01-21 13:30 A |  | 100% |  | Boris Nacinovic; Yan Morin | 7h | 7h | 35 | 35 |
| 3 | 1.2 | Apprentissage de la programme en Visual Basic | 3.5h | 2002-01-21 13:30 A | 2002-01-21 17:00 A | 2 | 100% |  | Yan Morin | 3.5h | 3.5h |  |  |
| 5 | 2 | **Analyse** | 7d | 2002-01-22 09:00 A | 2002-01-31 17:00 A | 1 | 100% |  |  | 63h | 63h | 55 | 55 |
| 6 | 2.1 | **Analyse avant la rencontre** | 1.86d | 2002-01-22 09:00 A | 2002-01-23 16:00 A |  | 100% |  |  | 22h | 22h | 35 | 35 |
| 7 | 2.1.1 | Aperçu du programme de gestion actuel | 3.5h | 2002-01-22 09:00 A | 2002-01-22 13:30 A |  | 100% |  | Yan Morin | 3.5h | 3.5h |  |  |
| 8 | 2.1.2 | Description du programme de gestion | 3.5h | 2002-01-22 13:30 A | 2002-01-22 17:00 A | 7 | 100% |  | Yan Morin | 3.5h | 3.5h |  |  |
| 9 | 2.1.3 | Documentation du programme de gestion actuel | 3.5h | 2002-01-23 08:00 A | 2002-01-23 13:30 A | 8 | 100% |  | Yan Morin | 4.5h | 4.5h |  |  |
| 10 | 2.1.4 | Rencontre avec l'usager du programme | 3.5h | 2002-01-23 11:30 A | 2002-01-23 16:00 A | 9 | 100% |  | Yan Morin; Emmanuelle Forger - Comptable; Boris Nacinovic | 10.5h | 10.5h | 35 | 35 |
| 11 | 2.2 | **Analyse après la rencontre** | 4d | 2002-01-24 09:00 A | 2002-01-30 17:00 A | 10 | 100% |  |  | 28h | 28h |  |  |
| 12 | 2.2.1 | Documentation (brouillon) de la rencontre | 3.5h | 2002-01-24 09:00 A | 2002-01-24 13:30 A |  | 100% | start no earlier than 2002-01-24 09:00 | Yan Morin | 3.5h | 3.5h |  |  |
| 13 | 2.2.2 | Schématisation (brouillon avec Word) de la rencontre | 3.5h | 2002-01-24 13:30 A | 2002-01-24 17:00 A | 12 | 100% |  | Yan Morin | 3.5h | 3.5h |  |  |
| 14 | 2.2.3 | Description des tables | 1.5h | 2002-01-28 09:00 A | 2002-01-28 10:30 A | 13 | 100% |  | Yan Morin | 1.5h | 1.5h |  |  |
| 15 | 2.2.4 | Description des champs | 3.5h | 2002-01-28 10:30 A | 2002-01-28 15:00 A | 14 | 100% |  | Yan Morin | 3.5h | 3.5h |  |  |
| 16 | 2.2.5 | Descriptions des relations | 3h | 2002-01-28 15:00 A | 2002-01-29 10:00 A | 15 | 100% |  | Yan Morin | 3h | 3h |  |  |
| 17 | 2.2.6 | Retour sur EAX et sur DFD | 1h | 2002-01-29 10:00 A | 2002-01-29 11:00 A | 16 | 100% |  | Yan Morin | 1h | 1h |  |  |
| 18 | 2.2.7 | Préparation du modèle EAX | 3h | 2002-01-29 11:00 A | 2002-01-29 15:00 A | 17 | 100% |  | Yan Morin | 3h | 3h |  |  |
| 19 | 2.2.8 | Séparation du modèle EAX (en 4) | 2h | 2002-01-29 15:00 A | 2002-01-29 17:00 A | 18 | 100% |  | Yan Morin | 2h | 2h |  |  |
| 20 | 2.2.9 | Préparation de 3 modèles DFD | 2h | 2002-01-30 09:00 A | 2002-01-30 11:00 A | 19 | 100% |  | Yan Morin | 2h | 2h |  |  |
| 21 | 2.2.10 | Vérification des tables | 1h | 2002-01-30 11:00 A | 2002-01-30 12:00 A | 20 | 100% |  | Yan Morin | 1h | 1h |  |  |
| 22 | 2.2.11 | Vérification des champs | 3.5h | 2002-01-30 13:00 A | 2002-01-30 16:30 A | 21 | 100% |  | Yan Morin | 3.5h | 3.5h |  |  |
| 23 | 2.2.12 | Vérification des relations | 30min | 2002-01-30 16:30 A | 2002-01-30 17:00 A | 22 | 100% |  | Yan Morin | 0.5h | 0.5h |  |  |
| 24 | 2.3 | **Présentation de l'analyse** | 1d | 2002-01-31 09:00 A | 2002-01-31 17:00 A | 23 | 100% |  |  | 13h | 13h | 20 | 20 |
| 25 | 2.3.1 | Préparation de la présentation PowerPoint | 3h | 2002-01-31 09:00 A | 2002-01-31 12:00 A |  | 100% |  | Yan Morin | 3h | 3h |  |  |
| 26 | 2.3.2 | Correction finale et ajustement | 2h | 2002-01-31 13:00 A | 2002-01-31 15:00 A | 25 | 100% |  | Yan Morin | 2h | 2h |  |  |
| 27 | 2.3.3 | Présentation (Comptable et Directeur du Marketing) | 2h | 2002-01-31 15:00 A | 2002-01-31 17:00 A | 26 | 100% |  | Yan Morin; Boris Nacinovic; Emmanuelle Forger - Comptable; Gilles Juteau - Vice-président, directeur marketing | 8h | 8h | 20 | 20 |

Notes:
- 1: Première journée : discusion sur l'environnement Visual Basic. / Premier exercice en Visual Basic, accès à une base de données et production d'un logiciel avec le style de NotePad.
- 2: Petit cours sur l'environnement Visual Basic. / - Création de projet / - Création de fenêtres MDI / - le principe Parent/Child / - Fermeture d'une fenêtre (unload me) / - Éditeur de menu
- 3: - Création d'un logiciel de texte / - Ouvrir et / - Enregistrer / - Ajout d'un lien vers une base de données Access / - Connexion.Execute ou RecordSet.AddNew
- 5: Récolte de l'information pour faire ressortir les besoins et les lacunes du logiciels actuels.
- 7: Navigation et premier essai du logiciel actuel. / Observation: / - Nombre de macros élevé / - Manque de tables (5) / - Champs vides / - Champs calculés
- 8: Production d'un document Word / - Relations existantes / - Liste des tables et de leur champs / - Liste des requêtes / - Liste des formulaires / - Liste des états et de leur requête / - Liste des macros
- 9: Production d'un document Word - 2 / - Complété les listes / - Mise en forme / - Impression
- 10: Rencontre avec la comptable / - Elle me décrit comment elle utilise le logiciel, les procédures d'utilisation. / Je note sur papier tous les champs obligatoires, calculés et je questionne / sur la manière qu'elle voudrait que j'améliore le système.
- 12: Production d'un document Word / - Inscription du brouillon / - Demande d'information sur des parties non-comprises / (éclaircissement) / - Listes des lacunes / - Listes des besoins (points à ajoutés)
- 13: Production d'un document Word - 2 / - Complété les listes des lacunes et besoins / - Mise en forme
- 14: Liste de la vingtaine de table
- 15: Liste des champs pour chaque table [Excel-Word] / Champs NuméroAuto, numérique, monétaire, date, texte, mémo...
- 16: Création d'une base de données avec les tables et les champs décrits dans le document Word. Liaisons des différentes tables.
- 17: Lecture de mes notes et du cahier sur EAX/DFD. / - Entités, relations, 1-N, 0-1... / - Installation du logiciel / - Téléchargement du démo de EAX.
- 18: Création à l'aide de Silverrun-EAX de chacune des tables [entités] avec leurs champs [éléments] et aussi les association qui les unissent.
- 19: Simplification du modèle EAX en 4 groupes. / - Étude / - Suivi / - Recette / - Déboursé
- 20: Production de trois modèle de données (DFD) / - Étude / - Suivi / - Recette et Déboursé / Permet de mieux comprendre la circulation de l'information / à travers le système.
- 21: Vérification et mise à jour, en même temps que la production des listes (word) / et la création d'entités (EAX), des tables.
- 22: Vérification et mise à jour, en même temps que la production des listes (word) / et l'entrée des éléments (EAX), des champs.
- 23: Vérification et mise à jour, en même temps que la production des listes (word) / et la créations des associations (EAX), des relations.
- 25: Création d'une présentation PowerPoint qui reprend les lacunes de l'anciens systèmes, les nouveaux besoins, les corrections à apportées et les scénarios. Les scénarios sont des manières d'interagir (protocole) avec le programme. Les scénarios du système actuel y sont présentés et d'autres scénarios y sont proposées.
- 26: Revision de la présentation / - correction des fautes d'orthographes (de français) / - ajout de schéma explicatif / - ajout d'élément de l'interface actuelle.
- 27: Longue présentation et discussion sur l'analyse. / - présentation powerpoint / - schémas EAX et DFD

| ID | WBS | Task | Duration | Start | Finish | Predecessors | Complete | Remaining | Total slack | Free slack | Constraint | Resources | Work | Actual work |
| --- | --- | --- | --- | --- | --- | --- | --- | --- | --- | --- | --- | --- | --- | --- |
| 29 | 3 | **Conception** | 8d | 2002-02-04 09:00 A | 2002-02-14 17:00 | 5 | 60% | 3.22d | 44d |  |  | Yan Morin | 56h | 16.8h |
| 30 | 3.1 | Programmation WEB - Javascript | 2h | 2002-02-04 09:00 A | 2002-02-04 11:00 A |  | 100% |  |  |  | start no earlier than 2002-02-04 09:00 |  |  |  |
| 31 | 3.2 | **Ébauche du logiciel** | 5d | 2002-02-04 11:00 A | 2002-02-12 11:00 |  | 51% | 2.46d | 4.3d |  |  |  |  |  |
| 32 | 3.2.1 | Fenêtre principale | 3h | 2002-02-04 11:00 A | 2002-02-04 15:00 | 30 | 60% | 1.2h | 6.58d | 0d |  |  |  |  |
| 33 | 3.2.2 | Fenêtre de démarrage | 3h | 2002-02-04 15:00 A | 2002-02-05 10:00 | 32 | 60% | 1.2h | 6.32d | 0d |  |  |  |  |
| 34 | 3.2.3 | Fenêtres de recherche | 1.5h | 2002-02-05 10:00 A | 2002-02-05 11:30 | 33 | 80% | 0.3h | 6.15d | 0d |  |  |  |  |
| 35 | 3.2.4 | Fenêtres des modes de paiement | 3h | 2002-02-05 11:30 A | 2002-02-05 15:30 | 34 | 60% | 1.2h | 5.89d | 0d |  |  |  |  |
| 36 | 3.2.5 | Fenêtre des protocoles | 3h | 2002-02-05 15:30 A | 2002-02-06 10:30 | 35 | 90% | 0.3h | 5.51d | 0d |  |  |  |  |
| 37 | 3.2.6 | Fenêtre des frais | 3h | 2002-02-06 10:30 A | 2002-02-06 14:30 | 36 | 80% | 0.6h | 5.17d | 0d |  |  |  |  |
| 38 | 3.2.7 | Fenêtre des recettes | 3h | 2002-02-06 14:30 A | 2002-02-07 09:30 | 37 | 60% | 1.2h | 4.91d | 0d |  |  |  |  |
| 39 | 3.2.8 | Fenêtre des déboursés | 3h | 2002-02-07 09:30 A | 2002-02-07 13:30 | 38 | 65% | 1.05h | 4.63d | 0d |  |  |  |  |
| 40 | 3.2.9 | Fenêtre de résumé | 2h | 2002-02-07 13:30 | 2002-02-07 15:30 | 39 |  |  | 4.63d | 0d |  |  |  |  |
| 41 | 3.2.10 | Retour sur l'analyse | 3.5h | 2002-02-07 15:30 | 2002-02-11 11:00 | 40 |  |  | 4.63d | 0d |  |  |  |  |
| 42 | 3.2.11 | Retour sur l'aspect graphique | 3.5h | 2002-02-11 11:00 A | 2002-02-11 15:30 | 41 | 33% | 2.35h | 4.46d | 0d |  |  |  |  |
| 43 | 3.2.12 | Uniformisation | 3.5h | 2002-02-11 15:30 A | 2002-02-12 11:00 | 42 | 33% | 2.35h | 4.3d | 0d |  |  |  |  |
| 44 | 3.3 | **Recherche des composantes** | 1.07d | 2002-02-12 11:00 A | 2002-02-13 11:30 | 43 | 76% | 0.26d | 0.86d |  |  |  |  |  |
| 45 | 3.3.1 | Icones et dessins | 3.5h | 2002-02-12 11:00 A | 2002-02-12 15:30 |  | 60% | 1.4h | 4.51d | 0d |  |  |  |  |
| 46 | 3.3.2 | Composantes OCX pour les grilles | 2h | 2002-02-12 15:30 A | 2002-02-13 09:30 | 45 | 90% | 0.2h | 4.26d | 0d |  |  |  |  |
| 47 | 3.3.3 | Formation sur les composantes de l'usager | 2h | 2002-02-13 09:30 A | 2002-02-13 11:30 | 46 | 90% | 0.2h | 0.86d | 0d |  |  |  |  |
| 48 | 3.4 | Présentation de la première ébauche | 3.5h | 2002-02-13 11:30 | 2002-02-13 16:00 | 47 |  |  | 0.86d |  |  |  |  |  |
| 49 | 3.5 | **Aide à la technicienne de laboratoire** | 1.14d | 2002-02-13 16:00 A | 2002-02-14 17:00 A | 48 | 100% |  |  |  |  |  |  |  |
| 50 | 3.5.1 | Publi-postage Word | 3h | 2002-02-13 16:00 A | 2002-02-14 11:00 A |  | 100% |  |  |  |  |  |  |  |
| 51 | 3.5.2 | Introduction à Excel | 3h | 2002-02-14 11:00 A | 2002-02-14 15:00 A | 50 | 100% |  |  |  |  |  |  |  |
| 52 | 3.5.3 | Introduction à la numérisation | 2h | 2002-02-14 15:00 A | 2002-02-14 17:00 A | 51 | 100% |  |  |  |  |  |  |  |

Notes:
- 29: Production d'une ébauche graphique du logiciel en montrant les possibilités que peuvent avoir le logiciel.
- 30: Aide au directeur informatique pour le site web du Dr. Tellier. / - Création d'une fonction pour l'affichage du image en "pop-up". / - Aide pour les balises et l'apparence du site (bgcolor, style).
- 32: Création d'une fenêtre principale MDI et création à l'aide de l'éditeur de menu des / différents menus de navigation. / Ajouter une barre de menu? / Aussi: création d'une fenêtre (popup) pour l'affichage des caractéristiques d'une étude (début, fin...)
- 33: Création d'une fenêtre (popup) qui apparaît lors du lancement de l'application et / qui permet d'obtenir les différentes fonctions du logiciel.
- 34: Fenêtre de recherche qui permettrait d'ouvrir une d'étude. / On entrerait un critère de recherche et on double-cliquerait sur une étude pour la modifier ou la consulter.
- 35: Tous les modes de paiements possible avec leur bonus ou non. / - Paiement aux intervenants pour les suivis, pour les recrutements ou autres frais. / - Paiement aux infirmières? / - Paiement aux sujets.
- 36: Liste des protocoles (par catégorie de visite) entrés au début de l'étude.
- 37: Liste des frais propres à une étude.
- 38: Fenêtre qui affiche des chèques (reçus) et les montants associés à tous les frais d'une étude / Puisqu'il existe une grande variétés de frais, cette fenêtre est très longue à faire.
- 39: Fenêtre qui affiche des chèques (envoyés) et les montants associés à tous les frais d'une étude / Elle est semblable à la fenêtres des recettes.
- 40: Résumé d'une étude avec la somme des frais, des recettes et des déboursés. / Bouton pour imprimer ce résumé.
- 41: Petite vérification pour ne pas oublier des choses.
- 42: Retouche et recherche d'îcones et de composantes pour améliorer la présentation graphique du logiciel.
- 43: Revision pour afficher un produit uniforme.
- 45: Recherche sur internet d'îcones et de dessins pour la conception de logiciel / - truc: soigné l'apparence d'un logiciel permet d'en mettre plein la vue au client.
- 46: Recherche de grille et apprentissage sur comment s'en servir et comment les remplir. / (MSFlexGrid). Merci à Boris.
- 47: Aide sur les différentes composantes (.ocx) en Visual Basic.
- 48: Présentation de la première ébauche du logiciel. / Peut-être en format PowerPoint pour éviter les bogues.
- 50: Explication à la technicienne de laboratoire les avantages du Publi-postage à l'aide de Word. / - lettre type / - choix de la base de données (données sources) / - ajout des champs / - impression du document
- 51: Aide sur le logiciel Excel / - Recopie-incrémenté, pied de page...
- 52: Aide pour numériser des feuilles et des photos / - Branchement du logiciel / - Sauvegarde des photos / - Paramétrages du logiciel d'acquisition

| ID | WBS | Task | Duration | Start | Finish | Predecessors | Total slack | Free slack | Constraint | Resources | Work |
| --- | --- | --- | --- | --- | --- | --- | --- | --- | --- | --- | --- |
| 55 | 4 | **Deuxième ébauche du logiciel** | 2.5d | 2002-02-18 09:00 | 2002-02-20 13:30 | 49 | 4d |  |  | Yan Morin | 17.5h |
| 56 | 4.1 | Documentation des améliorations à apporter | 3.5h | 2002-02-18 09:00 | 2002-02-18 13:30 |  | 4d | 0d |  |  |  |
| 57 | 4.2 | Modification des formulaires | 3.5h | 2002-02-18 13:30 | 2002-02-18 17:00 | 56 | 4d | 0d |  |  |  |
| 58 | 4.3 | Ajout/suppresion de formulaires | 3.5h | 2002-02-19 09:00 | 2002-02-19 13:30 | 57 | 4d | 0d |  |  |  |
| 59 | 4.4 | Finalisation du logiciel de démonstration | 3.5h | 2002-02-19 13:30 | 2002-02-19 17:00 | 58 | 4d | 0d |  |  |  |
| 60 | 4.5 | Présentation du logiciel de démonstration corrigé | 3.5h | 2002-02-20 09:00 | 2002-02-20 13:30 | 59 | 4d | 0d |  |  |  |
| 62 | 5 | **Conception détaillée** | 9.5d | 2002-02-20 13:30 | 2002-03-07 17:00 | 60 | 4d | 0d |  | Yan Morin | 66.5h |
| 63 | 5.1 | Discussion sur les rapports et accesibilité | 3.5h | 2002-02-20 13:30 | 2002-02-20 17:00 |  | 4d | 0d |  |  |  |
| 64 | 5.2 | Discusion sur les requêtes | 3.5h | 2002-02-21 09:00 | 2002-02-21 13:30 | 63 | 4d | 0d |  |  |  |
| 65 | 5.3 | Réflexion sur les requêtes | 3.5h | 2002-02-21 13:30 | 2002-02-21 17:00 | 64 | 4d | 0d |  |  |  |
| 66 | 5.4 | Discusion sur les résultats attendus | 3.5h | 2002-02-25 09:00 | 2002-02-25 13:30 | 65 | 4d | 0d |  |  |  |
| 67 | 5.5 | Discusion sur le système - Infirmière | 3.5h | 2002-02-25 13:30 | 2002-02-25 17:00 | 66 | 4d | 0d |  |  |  |
| 68 | 5.6 | Discusion sur le logiciel de programmation | 3.5h | 2002-02-26 09:00 | 2002-02-26 13:30 | 67 | 4d | 0d |  |  |  |
| 69 | 5.7 | **Apprentissage** | 3.29d | 2002-02-26 13:30 | 2002-03-04 15:30 | 68 | 4d | 0d |  |  |  |
| 70 | 5.7.1 | 1- Logiciel | 3.5h | 2002-02-26 13:30 | 2002-02-26 17:00 |  | 4d | 0d |  |  |  |
| 71 | 5.7.2 | 2- Exemples, tutoriels | 3.5h | 2002-02-27 09:00 | 2002-02-27 13:30 | 70 | 4d | 0d |  |  |  |
| 72 | 5.7.3 | 3- Convention, normes de travail | 3.5h | 2002-02-27 13:30 | 2002-02-27 17:00 | 71 | 4d | 0d |  |  |  |
| 73 | 5.7.4 | 4- Classe | 3.5h | 2002-02-28 09:00 | 2002-02-28 13:30 | 72 | 4d | 0d |  |  |  |
| 74 | 5.7.5 | 5- Modules | 2h | 2002-02-28 13:30 | 2002-02-28 15:30 | 73 | 4d | 0d |  |  |  |
| 75 | 5.7.6 | 6- Composantes VB | 3.5h | 2002-02-28 15:30 | 2002-03-04 11:00 | 74 | 4d | 0d |  |  |  |
| 76 | 5.7.7 | 7- Accès à la base de données | 3.5h | 2002-03-04 11:00 | 2002-03-04 15:30 | 75 | 4d |  |  |  |  |
| 77 | 5.8 | **Base de données** | 2.21d | 2002-03-04 15:30 | 2002-03-06 17:00 | 69 | 4d | 0d |  |  |  |
| 78 | 5.8.1 | Structuration de la base de données | 2h | 2002-03-04 15:30 | 2002-03-05 09:30 |  | 4d | 0d |  |  |  |
| 79 | 5.8.2 | Ajouts des descriptions | 3.5h | 2002-03-05 09:30 | 2002-03-05 14:00 | 78 | 4d | 0d |  |  |  |
| 80 | 5.8.3 | Confirmité des noms | 2.5h | 2002-03-05 14:00 | 2002-03-05 16:30 | 79 | 4d | 0d |  |  |  |
| 81 | 5.8.4 | Valeurs par défaut/fonctions | 2h | 2002-03-05 16:30 | 2002-03-06 10:30 | 80 | 4d | 0d |  |  |  |
| 82 | 5.8.5 | Format des champs | 2h | 2002-03-06 10:30 | 2002-03-06 13:30 | 81 | 4d | 0d |  |  |  |
| 83 | 5.8.6 | Visibilité et accesibilité | 3.5h | 2002-03-06 13:30 | 2002-03-06 17:00 | 82 | 4d |  |  |  |  |
| 84 | 5.9 | Support technique | 3.5h | 2002-03-07 09:00 | 2002-03-07 13:30 | 77 | 4d | 0d |  |  |  |
| 85 | 5.10 | Imprévus | 3.5h | 2002-03-07 13:30 | 2002-03-07 17:00 | 84 | 4d |  |  |  |  |
| 87 | 6 | Codage | 16d | 2002-03-11 09:00 | 2002-04-04 17:00 | 62 | 4d |  | start no earlier than 2002-03-11 09:00 | Yan Morin | 112h |
| 89 | 7 | Test | 2.5d | 2002-04-15 09:00 | 2002-04-17 13:30 | 87 | 0d |  | start no earlier than 2002-04-15 09:00 | Yan Morin | 17.5h |
| 91 | 8 | Implantation | 2.5d | 2002-04-17 13:30 | 2002-04-22 17:00 | 89 | 0d |  |  | Yan Morin | 17.5h |
| 93 | 9 | Vérification et documentation | 7d | 2002-04-23 09:00 | 2002-05-02 17:00 | 91 | 0d |  |  | Yan Morin | 49h |

Notes:
- 55: Dépend de la première conception... / On peut revenir souvent à cette étape s'il y a des petits problèmes où si de nouvelles informations (besoins/limites) surgissent avec le temps...
- 62: Tout ce qui touche des contraintes du logiciel, calculs utilisés, rapports que doit produire le logiciel.
- 69: Apprentissage grâce à MSDN, aux tutoriels sur le web et à des personnes ressources ou à l'aide de mes amis.
- 77: Opération de normalisation [application de norme], d'uniformisation de la base de données.
- 84: Temps prévus pour le dépannage aux usagers - hors logiciel.
- 85: Temps alloués à des imprévus - perte d'un formulaire, oublie d'enregistrer...
- 87: Trop loin pour connaître les tâches du codage avant la conception détaillée... / - Code des fenêtre / - Sécurité / - Interface / - Modules et classes / - Composantes / - Accès à la base de données / - Requêtes SQL (ADOBD) / - Remplir les grilles / - Calcul et totaux / - Protection des données / - Archivage / - Impression de chèque
- 89: Dépend de la programmation (codage)... des logiciels utilisés, des systèmes d'exploitations... de l'environnement de développement
- 91: Dépend du matériel, des systèmes d'exploitations, des outils utilisés pour l'installation et des ressources disponibles.
- 93: Intégration de l'aide et documentation des méthodes utilisées. / - Guide des programmeurs / - Guide des usagers / - Guide sur le langage utilisé / - Guide sur les différentes fonctions produites
