# YMorinSem3

Schedule from MS Project, 2002-01-21 to 2002-05-02, status date 2002-02-09, 7 hours a day, costs in $, A marks actual dates.
Cégep de St-Jérôme

## Calendars

- Yan Morin: Mon-Thu 09:00-12:00, 13:00-17:00; Fri-Sun off.

## Resources

| Resource | Rate |
| --- | --- |
| Yan Morin |  |
| Boris Nacinovic | 10 |
| Emmanuelle Forger - Comptable |  |
| Gilles Juteau - Vice-président, directeur marketing |  |

## Schedule

| ID | WBS | Task | Duration | Start | Finish | Predecessors | Complete | Baseline start | Baseline finish | Baseline duration | Constraint | Resources | Work | Actual work | Cost | Baseline cost | Actual cost |
| --- | --- | --- | --- | --- | --- | --- | --- | --- | --- | --- | --- | --- | --- | --- | --- | --- | --- |
| 1 | 1 | **Introduction en entreprise** | 1d | 2002-01-21 09:00 A | 2002-01-21 17:00 A |  | 100% | 2002-01-21 09:00 | 2002-01-21 17:00 | 1d |  |  | 10.5h | 10.5h | 35 | 35 | 35 |
| 2 | 1.1 | Apprentissage de l'environnement Visual Basic | 3.5h | 2002-01-21 09:00 A | 2002-01-21 13:30 A |  | 100% | 2002-01-21 09:00 | 2002-01-21 13:30 | 3.5h |  | Boris Nacinovic; Yan Morin | 7h | 7h | 35 | 35 | 35 |
| 3 | 1.2 | Apprentissage de la programme en Visual Basic | 3.5h | 2002-01-21 13:30 A | 2002-01-21 17:00 A | 2 | 100% | 2002-01-21 13:30 | 2002-01-21 17:00 | 3.5h |  | Yan Morin | 3.5h | 3.5h |  |  |  |
| 5 | 2 | **Analyse** | 7d | 2002-01-22 09:00 A | 2002-01-31 17:00 A | 1 | 100% | 2002-01-22 09:00 | 2002-01-31 17:00 | 7d |  |  | 63h | 63h | 55 | 55 | 55 |
| 6 | 2.1 | **Analyse avant la rencontre** | 1.86d | 2002-01-22 09:00 A | 2002-01-23 16:00 A |  | 100% | 2002-01-22 09:00 | 2002-01-23 16:00 | 1.86d |  |  | 22h | 22h | 35 | 35 | 35 |
| 7 | 2.1.1 | Aperçu du programme de gestion actuel | 3.5h | 2002-01-22 09:00 A | 2002-01-22 13:30 A |  | 100% | 2002-01-22 09:00 | 2002-01-22 13:30 | 3.5h |  | Yan Morin | 3.5h | 3.5h |  |  |  |
| 8 | 2.1.2 | Description du programme de gestion | 3.5h | 2002-01-22 13:30 A | 2002-01-22 17:00 A | 7 | 100% | 2002-01-22 13:30 | 2002-01-22 17:00 | 3.5h |  | Yan Morin | 3.5h | 3.5h |  |  |  |
| 9 | 2.1.3 | Documentation du programme de gestion actuel | 3.5h | 2002-01-23 08:00 A | 2002-01-23 13:30 A | 8 | 100% | 2002-01-23 08:00 | 2002-01-23 13:30 | 3.5h |  | Yan Morin | 4.5h | 4.5h |  |  |  |
| 10 | 2.1.4 | Rencontre avec l'usager du programme | 3.5h | 2002-01-23 11:30 A | 2002-01-23 16:00 A | 9 | 100% | 2002-01-23 11:30 | 2002-01-23 16:00 | 3.5h |  | Yan Morin; Emmanuelle Forger - Comptable; Boris Nacinovic | 10.5h | 10.5h | 35 | 35 | 35 |
| 11 | 2.2 | **Analyse après la rencontre** | 4d | 2002-01-24 09:00 A | 2002-01-30 17:00 A | 10 | 100% | 2002-01-24 09:00 | 2002-01-30 17:00 | 4d |  |  | 28h | 28h |  |  |  |
| 12 | 2.2.1 | Documentation (brouillon) de la rencontre | 3.5h | 2002-01-24 09:00 A | 2002-01-24 13:30 A |  | 100% | 2002-01-24 09:00 | 2002-01-24 13:30 | 3.5h | start no earlier than 2002-01-24 09:00 | Yan Morin | 3.5h | 3.5h |  |  |  |
| 13 | 2.2.2 | Schématisation (brouillon avec Word) de la rencontre | 3.5h | 2002-01-24 13:30 A | 2002-01-24 17:00 A | 12 | 100% | 2002-01-24 13:30 | 2002-01-24 17:00 | 3.5h |  | Yan Morin | 3.5h | 3.5h |  |  |  |
| 14 | 2.2.3 | Description des tables | 1.5h | 2002-01-28 09:00 A | 2002-01-28 10:30 A | 13 | 100% | 2002-01-28 09:00 | 2002-01-28 10:30 | 1.5h |  | Yan Morin | 1.5h | 1.5h |  |  |  |
| 15 | 2.2.4 | Description des champs | 3.5h | 2002-01-28 10:30 A | 2002-01-28 15:00 A | 14 | 100% | 2002-01-28 10:30 | 2002-01-28 15:00 | 3.5h |  | Yan Morin | 3.5h | 3.5h |  |  |  |
| 16 | 2.2.5 | Descriptions des relations | 3h | 2002-01-28 15:00 A | 2002-01-29 10:00 A | 15 | 100% | 2002-01-28 15:00 | 2002-01-29 10:00 | 3h |  | Yan Morin | 3h | 3h |  |  |  |
| 17 | 2.2.6 | Retour sur EAX et sur DFD | 1h | 2002-01-29 10:00 A | 2002-01-29 11:00 A | 16 | 100% | 2002-01-29 10:00 | 2002-01-29 11:00 | 1h |  | Yan Morin | 1h | 1h |  |  |  |
| 18 | 2.2.7 | Préparation du modèle EAX | 3h | 2002-01-29 11:00 A | 2002-01-29 15:00 A | 17 | 100% | 2002-01-29 11:00 | 2002-01-29 15:00 | 3h |  | Yan Morin | 3h | 3h |  |  |  |
| 19 | 2.2.8 | Séparation du modèle EAX (en 4) | 2h | 2002-01-29 15:00 A | 2002-01-29 17:00 A | 18 | 100% | 2002-01-29 15:00 | 2002-01-29 17:00 | 2h |  | Yan Morin | 2h | 2h |  |  |  |
| 20 | 2.2.9 | Préparation de 3 modèles DFD | 2h | 2002-01-30 09:00 A | 2002-01-30 11:00 A | 19 | 100% | 2002-01-30 09:00 | 2002-01-30 11:00 | 2h |  | Yan Morin | 2h | 2h |  |  |  |
| 21 | 2.2.10 | Vérification des tables | 1h | 2002-01-30 11:00 A | 2002-01-30 12:00 A | 20 | 100% | 2002-01-30 11:00 | 2002-01-30 12:00 | 1h |  | Yan Morin | 1h | 1h |  |  |  |
| 22 | 2.2.11 | Vérification des champs | 3.5h | 2002-01-30 13:00 A | 2002-01-30 16:30 A | 21 | 100% | 2002-01-30 13:00 | 2002-01-30 16:30 | 3.5h |  | Yan Morin | 3.5h | 3.5h |  |  |  |
| 23 | 2.2.12 | Vérification des relations | 30min | 2002-01-30 16:30 A | 2002-01-30 17:00 A | 22 | 100% | 2002-01-30 16:30 | 2002-01-30 17:00 | 30min |  | Yan Morin | 0.5h | 0.5h |  |  |  |
| 24 | 2.3 | **Présentation de l'analyse** | 1d | 2002-01-31 09:00 A | 2002-01-31 17:00 A | 23 | 100% | 2002-01-31 09:00 | 2002-01-31 17:00 | 1d |  |  | 13h | 13h | 20 | 20 | 20 |
| 25 | 2.3.1 | Préparation de la présentation PowerPoint | 3h | 2002-01-31 09:00 A | 2002-01-31 12:00 A |  | 100% | 2002-01-31 09:00 | 2002-01-31 12:00 | 3h |  | Yan Morin | 3h | 3h |  |  |  |
| 26 | 2.3.2 | Correction finale et ajustement | 2h | 2002-01-31 13:00 A | 2002-01-31 15:00 A | 25 | 100% | 2002-01-31 13:00 | 2002-01-31 15:00 | 2h |  | Yan Morin | 2h | 2h |  |  |  |
| 27 | 2.3.3 | Présentation (Comptable et Directeur du Marketing) | 2h | 2002-01-31 15:00 A | 2002-01-31 17:00 A | 26 | 100% | 2002-01-31 15:00 | 2002-01-31 17:00 | 2h |  | Yan Morin; Boris Nacinovic; Emmanuelle Forger - Comptable; Gilles Juteau - Vice-président, directeur marketing | 8h | 8h | 20 | 20 | 20 |

Notes:
- 1: Première journée : discusion sur l'environnement Visual Basic. / Premier exercice en Visual Basic, accès à une base de données et production d'un logiciel avec le style de NotePad.
- 2: Petit cours sur l'environnement Visual Basic. / - Création de projet / - Création de fenêtres MDI / - le principe Parent/Child / - Fermeture d'une fenêtre (unload me) / - Éditeur de menu
- 3: - Création d'un logiciel de texte / - Ouvrir et / - Enregistrer / - Ajout d'un lien vers une base de données Access / - Connexion.Execute ou RecordSet.AddNew
- 5: Récolte de l'information pour faire ressortir les besoins et les lacunes du logiciels actuels.
- 7: Navigation et premier essai du logiciel actuel. / Observation: / - Nombre de macros élevé / - Manque de tables (5) / - Champs vides / - Champs calculés
- 8: Production d'un document Word / - Relations existantes / - Liste des tables et de leur champs / - Liste des requêtes / - Liste des formulaires / - Liste des états et de leur requête / - Liste des macros
- 9: Production d'un document Word - 2 / - Complété les listes / - Mise en forme / - Impression
- 10: Rencontre avec la comptable / - Elle me décrit comment elle utilise le logiciel, les procédures d'utilisation. / Je note sur papier tous les champs obligatoires, calculés et je questionne / sur la manière qu'elle voudrait que j'améliore le système.
- 12: Production d'un document Word / - Inscription du brouillon / - Demande d'information sur des parties non-comprises / (éclaircissement) / - Listes des lacunes / - Listes des besoins (points à ajoutés)
- 13: Production d'un document Word - 2 / - Complété les listes des lacunes et besoins / - Mise en forme
- 14: Liste de la vingtaine de table
- 15: Liste des champs pour chaque table [Excel-Word] / Champs NuméroAuto, numérique, monétaire, date, texte, mémo...
- 16: Création d'une base de données avec les tables et les champs décrits dans le document Word. Liaisons des différentes tables.
- 17: Lecture de mes notes et du cahier sur EAX/DFD. / - Entités, relations, 1-N, 0-1... / - Installation du logiciel / - Téléchargement du démo de EAX.
- 18: Création à l'aide de Silverrun-EAX de chacune des tables [entités] avec leurs champs [éléments] et aussi les association qui les unissent.
- 19: Simplification du modèle EAX en 4 groupes. / - Étude / - Suivi / - Recette / - Déboursé
- 20: Production de trois modèle de données (DFD) / - Étude / - Suivi / - Recette et Déboursé / Permet de mieux comprendre la circulation de l'information / à travers le système.
- 21: Vérification et mise à jour, en même temps que la production des listes (word) / et la création d'entités (EAX), des tables.
- 22: Vérification et mise à jour, en même temps que la production des listes (word) / et l'entrée des éléments (EAX), des champs.
- 23: Vérification et mise à jour, en même temps que la production des listes (word) / et la créations des associations (EAX), des relations.
- 25: Création d'une présentation PowerPoint qui reprend les lacunes de l'anciens systèmes, les nouveaux besoins, les corrections à apportées et les scénarios. Les scénarios sont des manières d'interagir (protocole) avec le programme. Les scénarios du système actuel y sont présentés et d'autres scénarios y sont proposées.
- 26: Revision de la présentation / - correction des fautes d'orthographes (de français) / - ajout de schéma explicatif / - ajout d'élément de l'interface actuelle.
- 27: Longue présentation et discussion sur l'analyse. / - présentation powerpoint / - schémas EAX et DFD

| ID | WBS | Task | Duration | Start | Finish | Predecessors | Complete | Remaining | Baseline start | Baseline finish | Baseline duration | Total slack | Constraint | Resources | Work | Actual work |
| --- | --- | --- | --- | --- | --- | --- | --- | --- | --- | --- | --- | --- | --- | --- | --- | --- |
| 29 | 3 | **Conception** | 8d | 2002-02-04 09:00 A | 2002-02-14 17:00 | 5 | 99% | 0d | 2002-02-04 09:00 | 2002-02-14 17:00 | 8d | 0d |  | Yan Morin | 56h | 16.8h |
| 30 | 3.1 | Programmation WEB - Javascript | 2h | 2002-02-04 09:00 A | 2002-02-04 11:00 A |  | 100% |  | 2002-02-04 09:00 | 2002-02-04 11:00 | 2h |  | start no earlier than 2002-02-04 09:00 |  |  |  |
| 31 | 3.2 | **Ébauche du logiciel** | 5.5d | 2002-02-04 11:00 A | 2002-02-12 15:30 A |  | 100% |  | 2002-02-04 11:00 | 2002-02-12 15:30 | 5.5d |  |  |  |  |  |
| 32 | 3.2.1 | Fenêtre principale | 3h | 2002-02-04 11:00 A | 2002-02-04 15:00 A | 30 | 100% |  | 2002-02-04 11:00 | 2002-02-04 15:00 | 3h |  |  |  |  |  |
| 33 | 3.2.2 | Fenêtre de démarrage | 3h | 2002-02-04 15:00 A | 2002-02-05 10:00 A | 32 | 100% |  | 2002-02-04 15:00 | 2002-02-05 10:00 | 3h |  |  |  |  |  |
| 34 | 3.2.3 | Fenêtres de recherche | 1.5h | 2002-02-05 10:00 A | 2002-02-05 11:30 A | 33 | 100% |  | 2002-02-05 10:00 | 2002-02-05 11:30 | 1.5h |  |  |  |  |  |
| 35 | 3.2.4 | Fenêtres des modes de paiement | 3h | 2002-02-05 11:30 A | 2002-02-05 15:30 A | 34 | 100% |  | 2002-02-05 11:30 | 2002-02-05 15:30 | 3h |  |  |  |  |  |
| 36 | 3.2.5 | Fenêtre des protocoles | 3h | 2002-02-05 15:30 A | 2002-02-06 10:30 A | 35 | 100% |  | 2002-02-05 15:30 | 2002-02-06 10:30 | 3h |  |  |  |  |  |
| 37 | 3.2.6 | Fenêtre des frais | 3h | 2002-02-06 10:30 A | 2002-02-06 14:30 A | 36 | 100% |  | 2002-02-06 10:30 | 2002-02-06 14:30 | 3h |  |  |  |  |  |
| 38 | 3.2.7 | Fenêtre des recettes | 3h | 2002-02-06 14:30 A | 2002-02-07 09:30 A | 37 | 100% |  | 2002-02-06 14:30 | 2002-02-07 09:30 | 3h |  |  |  |  |  |
| 39 | 3.2.8 | Fenêtre des déboursés | 3h | 2002-02-07 09:30 A | 2002-02-07 13:30 A | 38 | 100% |  | 2002-02-07 09:30 | 2002-02-07 13:30 | 3h |  |  |  |  |  |
| 40 | 3.2.9 | Fenêtre de résumé | 2h | 2002-02-07 13:30 A | 2002-02-07 15:30 A | 39 | 100% |  | 2002-02-07 13:30 | 2002-02-07 15:30 | 2h |  |  |  |  |  |
| 41 | 3.2.10 | Retour sur l'analyse | 3.5h | 2002-02-07 15:30 A | 2002-02-11 11:00 A | 40 | 100% |  | 2002-02-07 15:30 | 2002-02-11 11:00 | 3.5h |  |  |  |  |  |
| 42 | 3.2.11 | Retour sur l'aspect graphique | 3.5h | 2002-02-11 11:00 A | 2002-02-11 15:30 A | 41 | 100% |  | 2002-02-11 11:00 | 2002-02-11 15:30 | 3.5h |  |  |  |  |  |
| 43 | 3.2.12 | Uniformisation | 3.5h | 2002-02-11 15:30 A | 2002-02-12 11:00 A | 42 | 100% |  | 2002-02-11 15:30 | 2002-02-12 11:00 | 3.5h |  |  |  |  |  |
| 44 | 3.2.13 | Fenêtre de résumé et d'impression | 3.5h | 2002-02-12 11:00 A | 2002-02-12 15:30 A | 43 | 100% |  | 2002-02-12 11:00 | 2002-02-12 15:30 | 3.5h |  |  |  |  |  |
| 45 | 3.3 | **Recherche des composantes** | 1.07d | 2002-02-12 11:00 A | 2002-02-13 11:30 A | 31 | 100% |  | 2002-02-12 11:00 | 2002-02-13 11:30 | 1.07d |  |  |  |  |  |
| 46 | 3.3.1 | Icones et dessins | 3.5h | 2002-02-12 11:00 A | 2002-02-12 15:30 A |  | 100% |  | 2002-02-12 11:00 | 2002-02-12 15:30 | 3.5h |  |  |  |  |  |
| 47 | 3.3.2 | Composantes OCX pour les grilles | 2h | 2002-02-12 15:30 A | 2002-02-13 09:30 A | 46 | 100% |  | 2002-02-12 15:30 | 2002-02-13 09:30 | 2h |  |  |  |  |  |
| 48 | 3.3.3 | Formation sur les composantes de l'usager | 2h | 2002-02-13 09:30 A | 2002-02-13 11:30 A | 47 | 100% |  | 2002-02-13 09:30 | 2002-02-13 11:30 | 2h |  |  |  |  |  |
| 49 | 3.3.4 | Recherche de pilotes et de script Visual Basic | 3h | 2002-02-12 11:00 A | 2002-02-12 15:00 A | 48 | 100% |  | 2002-02-12 11:00 | 2002-02-12 15:00 | 3h |  |  |  |  |  |
| 50 | 3.4 | Présentation de la première ébauche | 3.5h | 2002-02-12 15:00 A | 2002-02-13 10:30 A | 49 | 100% |  | 2002-02-12 15:00 | 2002-02-13 10:30 | 3.5h |  |  |  |  |  |
| 51 | 3.5 | **Aide et support technique** | 1.14d | 2002-02-13 16:00 A | 2002-02-14 17:00 A | 45 | 100% |  | 2002-02-13 16:00 | 2002-02-14 17:00 | 1.14d |  |  |  |  |  |
| 52 | 3.5.1 | Publi-postage Word | 3h | 2002-02-13 16:00 A | 2002-02-14 11:00 A |  | 100% |  | 2002-02-13 16:00 | 2002-02-14 11:00 | 3h |  |  |  |  |  |
| 53 | 3.5.2 | Introduction à Excel | 3h | 2002-02-14 11:00 A | 2002-02-14 15:00 A | 52 | 100% |  | 2002-02-14 11:00 | 2002-02-14 15:00 | 3h |  |  |  |  |  |
| 54 | 3.5.3 | Introduction à la numérisation | 2h | 2002-02-14 15:00 A | 2002-02-14 17:00 A | 53 | 100% |  | 2002-02-14 15:00 | 2002-02-14 17:00 | 2h |  |  |  |  |  |

Notes:
- 29: Production d'une ébauche graphique du logiciel en montrant les possibilités que peuvent avoir le logiciel.
- 30: Aide au directeur informatique pour le site web du Dr. Tellier. / - Création d'une fonction pour l'affichage du image en "pop-up". / - Aide pour les balises et l'apparence du site (bgcolor, style).
- 32: Création d'une fenêtre principale MDI et création à l'aide de l'éditeur de menu des / différents menus de navigation. / Ajouter une barre de menu? / Aussi: création d'une fenêtre (popup) pour l'affichage des caractéristiques d'une étude (début, fin...)
- 33: Création d'une fenêtre (popup) qui apparaît lors du lancement de l'application et / qui permet d'obtenir les différentes fonctions du logiciel.
- 34: Fenêtre de recherche qui permettrait d'ouvrir une d'étude. / On entrerait un critère de recherche et on double-cliquerait sur une étude pour la modifier ou la consulter.
- 35: Tous les modes de paiements possible avec leur bonus ou non. / - Paiement aux intervenants pour les suivis, pour les recrutements ou autres frais. / - Paiement aux infirmières? / - Paiement aux sujets.
- 36: Liste des protocoles (par catégorie de visite) entrés au début de l'étude.
- 37: Liste des frais propres à une étude.
- 38: Fenêtre qui affiche des chèques (reçus) et les montants associés à tous les frais d'une étude / Puisqu'il existe une grande variétés de frais, cette fenêtre est très longue à faire.
- 39: Fenêtre qui affiche des chèques (envoyés) et les montants associés à tous les frais d'une étude / Elle est semblable à la fenêtres des recettes.
- 40: Résumé d'une étude avec la somme des frais, des recettes et des déboursés. / Bouton pour imprimer ce résumé.
- 41: Petite vérification pour ne pas oublier des choses.
- 42: Retouche et recherche d'îcones et de composantes pour améliorer la présentation graphique du logiciel.
- 43: Revision pour afficher un produit uniforme.
- 44: Fenêtre affichant un résumé des recettes et déboursés pour une étude. / Fenêtre affichant les différents type d'impression (rapports global où spécifique). / Fenêtre d'archivage pour archiver les études où les rétablir.
- 46: Recherche sur internet d'îcones et de dessins pour la conception de logiciel / - truc: soigné l'apparence d'un logiciel permet d'en mettre plein la vue au client.
- 47: Recherche de grille et apprentissage sur comment s'en servir et comment les remplir. / (MSFlexGrid). Merci à Boris.
- 48: Aide sur les différentes composantes (.ocx) en Visual Basic.
- 49: Recherche de pilotes pour l'imprimante HP de la secrétaire et d'astuces pour ralentir le temps de démarrage de Windows 2000. Je n'ai rien trouvé jusqu'à maintenant pour Windows 2000. J'ai aussi communiqué avec Alain Boudreault mais il ne m'a pas répondu sur ce sujet....
- 50: Présentation de la première ébauche du logiciel. / Peut-être en format PowerPoint pour éviter les bogues.
- 52: Explication à la technicienne de laboratoire les avantages du Publi-postage à l'aide de Word. / - lettre type / - choix de la base de données (données sources) / - ajout des champs / - impression du document
- 53: Aide sur le logiciel Excel / - Recopie-incrémenté, pied de page...
- 54: Aide pour numériser des feuilles et des photos / - Branchement du logiciel / - Sauvegarde des photos / - Paramétrages du logiciel d'acquisition

| ID | WBS | Task | Duration | Start | Finish | Predecessors | Complete | Remaining | Baseline start | Baseline finish | Baseline duration | Total slack | Free slack | Constraint | Resources | Work | Actual work |
| --- | --- | --- | --- | --- | --- | --- | --- | --- | --- | --- | --- | --- | --- | --- | --- | --- | --- |
| 57 | 4 | **Deuxième ébauche du logiciel** | 6d | 2002-02-18 09:00 A | 2002-02-26 17:00 | 51 | 69% | 1.87d | 2002-02-18 09:00 | 2002-02-26 17:00 | 6d | 0.57d | 0d |  | Yan Morin | 42h | 38.93h |
| 58 | 4.1 | Documentation des améliorations à apporter | 2h | 2002-02-18 09:00 A | 2002-02-18 11:00 A |  | 100% |  | 2002-02-18 09:00 | 2002-02-18 11:00 | 2h |  |  |  |  |  |  |
| 59 | 4.2 | Modification des formulaires | 2h | 2002-02-18 13:30 A | 2002-02-18 15:30 A | 58 | 100% |  | 2002-02-18 13:30 | 2002-02-18 15:30 | 2h |  |  |  |  |  |  |
| 60 | 4.3 | Ajout/suppresion de formulaires | 3h | 2002-02-19 09:00 A | 2002-02-19 12:00 A | 59 | 100% |  | 2002-02-19 09:00 | 2002-02-19 12:00 | 3h |  |  |  |  |  |  |
| 61 | 4.4 | Système de gestion des bonis de rendement des infirmière | 1h | 2002-02-20 13:30 A | 2002-02-20 14:30 A | 60 | 100% |  | 2002-02-20 13:30 | 2002-02-20 14:30 | 1h |  |  |  |  |  |  |
| 62 | 4.5 | Documentation, analyse, modification de la base de données | 2h | 2002-02-20 14:30 A | 2002-02-20 16:30 A | 61 | 100% |  | 2002-02-20 14:30 | 2002-02-20 16:30 | 2h |  |  |  |  |  |  |
| 63 | 4.6 | Attente de clarification et de réponse sur les infirmière | 2h | 2002-02-21 10:00 A | 2002-02-21 12:00 A | 62 | 100% |  | 2002-02-21 10:00 | 2002-02-21 12:00 | 2h |  |  |  |  |  |  |
| 64 | 4.7 | Rencontre finale sur le module "infirmière" | 1.5h | 2002-02-21 14:30 A | 2002-02-21 16:00 A | 63 | 100% |  | 2002-02-21 14:30 | 2002-02-21 16:00 | 1.5h |  |  |  |  |  |  |
| 65 | 4.8 | Finalisation du logiciel de démonstration | 3.5h | 2002-02-26 09:00 | 2002-02-26 13:30 | 69 |  |  | 2002-02-26 09:00 | 2002-02-26 13:30 | 3.5h | 0.57d | 0d | start no earlier than 2002-02-26 09:00 |  |  |  |
| 66 | 4.9 | Présentation du logiciel de démonstration corrigé | 3.5h | 2002-02-26 13:30 | 2002-02-26 17:00 | 65 |  |  | 2002-02-26 13:30 | 2002-02-26 17:00 | 3.5h | 0.57d |  |  |  |  |  |
| 67 | 4.10 | **Formation 2** | 0.14d | 2002-02-21 09:00 A | 2002-02-21 10:00 A | 64 | 100% |  | 2002-02-21 09:00 | 2002-02-21 10:00 | 0.14d |  |  |  |  |  |  |
| 68 | 4.10.1 | Excel (pied de page, feuille et zone d'impression) | 1h | 2002-02-21 09:00 A | 2002-02-21 10:00 A |  | 100% |  | 2002-02-21 09:00 | 2002-02-21 10:00 | 1h |  |  | start no earlier than 2002-02-23 09:00 |  |  |  |
| 69 | 4.10.2 | Word (case à cocher, caractères spéciaux, archivage Winzip) | 1h | 2002-02-21 09:00 A | 2002-02-21 10:00 A | 68 | 100% |  | 2002-02-21 09:00 | 2002-02-21 10:00 | 1h |  |  | start no earlier than 2002-02-23 09:00 |  |  |  |
| 71 | 5 | **Conception détaillée** | 10d | 2002-02-21 09:00 A | 2002-03-11 17:00 | 57 | 6% | 9.38d | 2002-02-21 09:00 | 2002-03-11 17:00 | 10d | 3d | 0d |  |  | 18.5h | 3.98h |
| 72 | 5.1 | Discussion sur les rapports et accesibilité | 3.5h | 2002-02-25 10:00 A | 2002-02-27 09:52 |  | 75% | 0.88h | 2002-02-25 10:00 | 2002-02-27 09:52 | 3.5h | 8.43d | 0d | start no earlier than 2002-02-21 09:00 | Yan Morin | 3.5h | 2.62h |
| 73 | 5.2 | Discusion sur les requêtes | 3.5h | 2002-02-27 09:52 | 2002-02-27 14:22 | 72 |  |  | 2002-02-27 09:52 | 2002-02-27 14:22 | 3.5h | 8.43d | 0d |  | Yan Morin | 3.5h |  |
| 74 | 5.3 | Réflexion sur les requêtes | 3.5h | 2002-02-27 14:22 | 2002-02-28 09:52 | 73 |  |  | 2002-02-27 14:22 | 2002-02-28 09:52 | 3.5h | 8.43d | 0d |  | Yan Morin | 3.5h |  |
| 75 | 5.4 | Discusion sur les résultats attendus | 3.5h | 2002-02-28 09:52 A | 2002-02-28 14:22 | 74 | 10% | 3.15h | 2002-02-28 09:52 | 2002-02-28 14:22 | 3.5h | 8.38d |  |  | Yan Morin | 3.5h | 0.35h |
| 76 | 5.5 | Discusion sur le système - Infirmière | 1h | 2002-02-21 09:00 A | 2002-02-21 10:00 A | 75 | 100% |  | 2002-02-21 09:00 | 2002-02-21 10:00 | 1h |  |  |  | Yan Morin | 1h | 1h |
| 77 | 5.6 | Discusion sur le logiciel de programmation | 3.5h | 2002-02-27 09:00 | 2002-02-27 13:30 | 76 |  |  | 2002-02-27 09:00 | 2002-02-27 13:30 | 3.5h | 3d | 0d |  | Yan Morin | 3.5h |  |
| 78 | 5.7 | **Apprentissage** | 3.29d | 2002-02-27 13:30 | 2002-03-05 15:30 | 77 |  |  | 2002-02-27 13:30 | 2002-03-05 15:30 | 3.29d | 3d | 0d |  |  |  |  |
| 79 | 5.7.1 | 1- Logiciel | 3.5h | 2002-02-27 13:30 | 2002-02-27 17:00 |  |  |  | 2002-02-27 13:30 | 2002-02-27 17:00 | 3.5h | 3d | 0d |  |  |  |  |
| 80 | 5.7.2 | 2- Exemples, tutoriels | 3.5h | 2002-02-28 09:00 | 2002-02-28 13:30 | 79 |  |  | 2002-02-28 09:00 | 2002-02-28 13:30 | 3.5h | 3d | 0d |  |  |  |  |
| 81 | 5.7.3 | 3- Convention, normes de travail | 3.5h | 2002-02-28 13:30 | 2002-02-28 17:00 | 80 |  |  | 2002-02-28 13:30 | 2002-02-28 17:00 | 3.5h | 3d | 0d |  |  |  |  |
| 82 | 5.7.4 | 4- Classe | 3.5h | 2002-03-04 09:00 | 2002-03-04 13:30 | 81 |  |  | 2002-03-04 09:00 | 2002-03-04 13:30 | 3.5h | 3d | 0d |  |  |  |  |
| 83 | 5.7.5 | 5- Modules | 2h | 2002-03-04 13:30 | 2002-03-04 15:30 | 82 |  |  | 2002-03-04 13:30 | 2002-03-04 15:30 | 2h | 3d | 0d |  |  |  |  |
| 84 | 5.7.6 | 6- Composantes VB | 3.5h | 2002-03-04 15:30 | 2002-03-05 11:00 | 83 |  |  | 2002-03-04 15:30 | 2002-03-05 11:00 | 3.5h | 3d | 0d |  |  |  |  |
| 85 | 5.7.7 | 7- Accès à la base de données | 3.5h | 2002-03-05 11:00 | 2002-03-05 15:30 | 84 |  |  | 2002-03-05 11:00 | 2002-03-05 15:30 | 3.5h | 3d |  |  |  |  |  |

Notes:
- 57: Dépend de la première conception... / On peut revenir souvent à cette étape s'il y a des petits problèmes où si de nouvelles informations (besoins/limites) surgissent avec le temps...
- 58: Écriture des différents changements à apporter par rapport à la première esquisse, tel ajout de différent total, ajout d'icône pour l'impression où ajout d'option.
- 59: Modification suite à la première discusion sur l'affichage.
- 60: Ajout de la gestion des bonis aux infirmières et de formulaire pour la gestion de la base de données.
- 61: Compréhension de ce système qui n'a pas été évoqué jusqu'à présent. (M. Juteau)
- 62: Documentation de ma compréhension sur la gestion des bonis de rendement. Ajout des tables, des champs, schémas EAX des relations entre ces tables et ajout dans Access des tables.
- 63: Ce temps a été long car M. Juteau est très occupé. J'ai quand même pris le temps de faire un brouillon des rapports et j'ai appris en regardant mon coordonnateur de stage (Boris) lors qu'il travaillait en VB.
- 64: Rencontre jeudi après-midi pour la clarification et la dernière explication sur la gestion des bonis aux infirmières. J'ai enfin compris toutes les modifications que j'avais à effectuer et ça n'a pas été trop difficile. Seulement les relations avec les déboursés et les recettes m'ont posé un problème, mais une discussion avec Boris m'a décidé sur la façon de faire.
- 65: Vérification des options ajoutées.
- 66: Présentation si vraiment nécessaire des changements effectués. La présentation se fera après avoir complété les rapports.
- 68: Support à Josée Courtemanche pour des problèmes avec Excel. Présentation d'astuce, de manière de travailler avec ce logiciel, d'options du logiciel.
- 69: Support technique pour le logiciel Word et les cases à cocher de Microsoft, aussi copier-coller...
- 71: Tout ce qui touche des contraintes du logiciel, calculs utilisés, rapports que doit produire le logiciel.
- 72: J'ai commencé à schématiser les différents rapports demandés par la comptable. J'ai aussi demandé jeudi soir à la comptable une liste des rapports qu'elle utilisait et qu'elle aimerait avoir.
- 76: Cette discusion m'a permis de compléter la base de données et de faire l'écran correspondant dans ma présentation Visual Basic. Fenêtre des bonis, des équipes d'infirmières. De plus, un renseignement venant d'un infirmier m'a appris un renseignement important sur les visites et les paiements au sujet.
- 78: Apprentissage grâce à MSDN, aux tutoriels sur le web et à des personnes ressources ou à l'aide de mes amis.

| ID | WBS | Task | Duration | Start | Finish | Predecessors | Baseline start | Baseline finish | Baseline duration | Total slack | Free slack | Constraint | Resources | Work |
| --- | --- | --- | --- | --- | --- | --- | --- | --- | --- | --- | --- | --- | --- | --- |
| 86 | 5.8 | **Base de données** | 2.21d | 2002-03-05 15:30 | 2002-03-07 17:00 | 78 | 2002-03-05 15:30 | 2002-03-07 17:00 | 2.21d | 3d | 0d |  |  |  |
| 87 | 5.8.1 | Structuration de la base de données | 2h | 2002-03-05 15:30 | 2002-03-06 09:30 |  | 2002-03-05 15:30 | 2002-03-06 09:30 | 2h | 3d | 0d |  |  |  |
| 88 | 5.8.2 | Ajouts des descriptions | 3.5h | 2002-03-06 09:30 | 2002-03-06 14:00 | 87 | 2002-03-06 09:30 | 2002-03-06 14:00 | 3.5h | 3d | 0d |  |  |  |
| 89 | 5.8.3 | Confirmité des noms | 2.5h | 2002-03-06 14:00 | 2002-03-06 16:30 | 88 | 2002-03-06 14:00 | 2002-03-06 16:30 | 2.5h | 3d | 0d |  |  |  |
| 90 | 5.8.4 | Valeurs par défaut/fonctions | 2h | 2002-03-06 16:30 | 2002-03-07 10:30 | 89 | 2002-03-06 16:30 | 2002-03-07 10:30 | 2h | 3d | 0d |  |  |  |
| 91 | 5.8.5 | Format des champs | 2h | 2002-03-07 10:30 | 2002-03-07 13:30 | 90 | 2002-03-07 10:30 | 2002-03-07 13:30 | 2h | 3d | 0d |  |  |  |
| 92 | 5.8.6 | Visibilité et accesibilité | 3.5h | 2002-03-07 13:30 | 2002-03-07 17:00 | 91 | 2002-03-07 13:30 | 2002-03-07 17:00 | 3.5h | 3d |  |  |  |  |
| 93 | 5.9 | Support technique | 3.5h | 2002-03-11 09:00 | 2002-03-11 13:30 | 86 | 2002-03-11 09:00 | 2002-03-11 13:30 | 3.5h | 3d | 0d |  |  |  |
| 94 | 5.10 | Imprévus | 3.5h | 2002-03-11 13:30 | 2002-03-11 17:00 | 93 | 2002-03-11 13:30 | 2002-03-11 17:00 | 3.5h | 3d |  |  |  |  |
| 96 | 6 | Codage | 16d | 2002-03-12 09:00 | 2002-04-08 17:00 | 71 | 2002-03-12 09:00 | 2002-04-08 17:00 | 16d | 3d |  | start no earlier than 2002-03-11 09:00 | Yan Morin | 112h |
| 98 | 7 | Test | 2.5d | 2002-04-15 09:00 | 2002-04-17 13:30 | 96 | 2002-04-15 09:00 | 2002-04-17 13:30 | 2.5d | 0d |  | start no earlier than 2002-04-15 09:00 | Yan Morin | 17.5h |
| 100 | 8 | Implantation | 2.5d | 2002-04-17 13:30 | 2002-04-22 17:00 | 98 | 2002-04-17 13:30 | 2002-04-22 17:00 | 2.5d | 0d |  |  | Yan Morin | 17.5h |
| 102 | 9 | Vérification et documentation | 7d | 2002-04-23 09:00 | 2002-05-02 17:00 | 100 | 2002-04-23 09:00 | 2002-05-02 17:00 | 7d | 0d |  |  | Yan Morin | 49h |

Notes:
- 86: Opération de normalisation [application de norme], d'uniformisation de la base de données.
- 93: Temps prévus pour le dépannage aux usagers - hors logiciel.
- 94: Temps alloués à des imprévus - perte d'un formulaire, oublie d'enregistrer...
- 96: Trop loin pour connaître les tâches du codage avant la conception détaillée... / - Code des fenêtre / - Sécurité / - Interface / - Modules et classes / - Composantes / - Accès à la base de données / - Requêtes SQL (ADOBD) / - Remplir les grilles / - Calcul et totaux / - Protection des données / - Archivage / - Impression de chèque
- 98: Dépend de la programmation (codage)... des logiciels utilisés, des systèmes d'exploitations... de l'environnement de développement
- 100: Dépend du matériel, des systèmes d'exploitations, des outils utilisés pour l'installation et des ressources disponibles.
- 102: Intégration de l'aide et documentation des méthodes utilisées. / - Guide des programmeurs / - Guide des usagers / - Guide sur le langage utilisé / - Guide sur les différentes fonctions produites
